# Target Hall shedule 130 Apr to Sep

Schedule from MS Project, 2016-04-25 to 2016-09-07, A marks actual dates.

## Calendars

- Standard: Mon-Fri 08:00-12:00, 13:00-17:00; Sat-Sun off.

## Resources

| Resource |
| --- |
| Wang.D |
| Cave.T |
| Fisher.C |
| Mjos.A |
| RPG |
| Target group |
| Mcdonald.D |

## Schedule

| ID | WBS | Task | Duration | Start | Finish | Predecessors | Complete | Remaining | Total slack | Free slack | Constraint | Resources | Work | Actual work |
| --- | --- | --- | --- | --- | --- | --- | --- | --- | --- | --- | --- | --- | --- | --- |
| 1 | 1 | **TM2 LpTa Ready for ITW** | 30d | 2016-04-25 08:00 A | 2016-06-03 17:00 |  | 40% | 18.08d | 68d |  |  |  | 275.04h | 120h |
| 2 | 1.1 | TM2 Leak Check -TCS | 5d | 2016-04-25 08:00 A | 2016-04-29 17:00 A |  | 100% |  |  |  | start no earlier than 2016-04-25 08:00 | Mjos.A; Wang.D | 80h | 80h |
| 3 | 1.2 | Module Move-TM2-TCS to silo | 0.5d | 2016-05-02 08:00 A | 2016-05-02 12:00 A |  | 100% |  |  |  | start no earlier than 2016-05-02 08:00 | Cave.T; Wang.D | 8h | 8h |
| 4 | 1.3 | Module Move-TM3-Silo to TCS | 0.5d | 2016-05-02 13:00 A | 2016-05-02 17:00 A | 3 | 100% |  |  |  | finish no earlier than 2016-05-02 17:00 | Cave.T; Wang.D | 8h | 8h |
| 5 | 1.4 | TM3 Inspection-TCS | 3d | 2016-05-03 08:00 A | 2016-05-05 17:00 | 4 | 50% | 1.5d | 88d | 1d | start no earlier than 2016-05-03 08:00 | Target group; Mcdonald.D | 48h | 24h |
| 6 | 1.5 | Shielding Block transfer-ITW to ITE | 1d | 2016-05-06 08:00 | 2016-05-06 17:00 |  |  |  | 88d |  | start no earlier than 2016-05-06 08:00 | Wang.D | 8h |  |
| 7 | 1.6 | Module Move-TM3-TCS to Silo | 0.5d | 2016-05-09 08:00 | 2016-05-09 12:00 | 5 |  |  | 87d | 0d | start no earlier than 2016-05-09 08:00 | Cave.T; Wang.D | 8h |  |
| 8 | 1.7 | Moduel Move-TM2 Silo to SHC | 0.5d | 2016-05-09 13:00 | 2016-05-09 17:00 | 7 |  |  | 87d |  | start no earlier than 2016-05-09 08:00 | Cave.T; Wang.D | 8h |  |
| 9 | 1.8 | Window Line Gaskets installation-TM2 -SHC | 1d | 2016-05-10 08:00 | 2016-05-10 17:00 |  |  |  | 78.12d | 1d | start no earlier than 2016-05-10 08:00 | Fisher.C | 8h |  |
| 10 | 1.9 | Lp Ta Target Insert -SHC | 0.5d | 2016-05-12 08:00 | 2016-05-12 12:00 | 9 |  |  | 77.12d | 0d | start no earlier than 2016-05-12 08:00 | Fisher.C; Mjos.A | 8h |  |
| 11 | 1.10 | Target Installation/Electrical Check | 0.5d | 2016-05-12 13:00 | 2016-05-12 17:00 | 10 |  |  | 77.12d | 0d | start no earlier than 2016-05-11 08:00 | Cave.T; Fisher.C; Wang.D | 12h |  |
| 12 | 1.11 | Moudle Move-TM2-SHC to TCS | 0.5d | 2016-05-13 08:00 | 2016-05-13 12:00 | 11 |  |  | 77.12d | 0d | start no earlier than 2016-05-12 08:00 | Cave.T; Wang.D | 8h |  |
| 13 | 1.12 | Module Connection-TM2-TSC/Start of Pumps | 0.5d | 2016-05-13 13:00 | 2016-05-13 17:00 | 12 |  |  | 77.12d | 1d | start no earlier than 2016-05-12 08:00 | Wang.D | 4h |  |
| 14 | 1.13 | Camera Setting up-ITW | 0.13d | 2016-05-17 08:00 | 2016-05-17 09:02 | 13 |  |  | 76.12d | 0d | start no earlier than 2016-05-17 08:00 | Cave.T | 1.04h |  |
| 15 | 1.14 | Module Disconnection-TM1-ITW | 0.37d | 2016-05-17 09:02 | 2016-05-17 12:00 | 14 |  |  | 76.12d | 0d | start no earlier than 2016-05-17 08:00 | Wang.D | 2.96h |  |
| 16 | 1.15 | Module Move -TM1-SHC | 0.25d | 2016-05-17 13:00 | 2016-05-17 15:00 | 15 |  |  | 76.12d | 0d | start no earlier than 2016-05-17 08:00 | Cave.T; Wang.D | 4h |  |
| 17 | 1.16 | Target Remove-TM1-SHC | 0.13d | 2016-05-17 15:00 | 2016-05-17 16:02 | 16 |  |  | 76.12d | 0.12d | start no earlier than 2016-05-17 08:00 | Fisher.C | 1.04h |  |
| 18 | 1.17 | Module Move-TM1-SHC to Silo | 1d | 2016-05-18 08:00 | 2016-05-18 17:00 | 17 |  |  | 76d | 2d | start no earlier than 2016-05-18 08:00 | Cave.T; Wang.D | 16h |  |
| 19 | 1.18 | Spent Target Move | 1d | 2016-06-03 08:00 | 2016-06-03 17:00 | 18 |  |  | 68d |  | start no earlier than 2016-06-03 08:00 | Cave.T; Fisher.C; Wang.D | 24h |  |
| 20 | 1.19 | Module Disconnection-TM2-TCS | 0.25d | 2016-05-25 08:00 | 2016-05-25 10:00 |  |  |  | 74d | 0d | start no earlier than 2016-05-25 08:00 | Wang.D | 2h |  |
| 21 | 1.20 | Module Move -TM2-ITW | 0.25d | 2016-05-25 10:00 | 2016-05-25 12:00 | 20 |  |  | 74d | 0d | start no earlier than 2016-05-25 08:00 | Cave.T; Wang.D | 4h |  |
| 22 | 1.21 | Module Connection- TM2-ITW/ Start of Pumps | 0.5d | 2016-05-25 13:00 | 2016-05-25 17:00 | 21 |  |  | 74d | 2d | start no earlier than 2016-05-25 08:00 | Wang.D | 4h |  |
| 23 | 1.22 | Shielding Blocks Transfer-ITE to ITW | 1d | 2016-05-30 08:00 | 2016-05-30 17:00 | 22 |  |  | 72d |  | start no earlier than 2016-05-30 08:00 | Wang.D | 8h |  |
| 24 | 2 | **TM4 LP Ucx Ready for ITE** | 15d | 2016-06-07 08:00 | 2016-06-27 17:00 |  |  |  | 52d |  |  |  | 55.2h |  |
| 25 | 2.1 | LpUCx target Insert to SHC | 0.1d | 2016-06-07 08:00 | 2016-06-07 08:48 |  |  |  | 66.7d | 0.7d | start no earlier than 2016-06-07 08:00 | Fisher.C; Mjos.A | 1.6h |  |
| 26 | 2.2 | Module Disconnection-TM4 -ITE | 0.2d | 2016-06-07 15:24 | 2016-06-07 17:00 | 25 |  |  | 66d |  | finish no earlier than 2016-06-07 17:00 | Wang.D | 1.6h |  |
| 27 | 2.3 | Module Move-TM4-ITE to SHC | 0.2d | 2016-06-07 08:00 | 2016-06-07 09:36 |  |  |  | 60.25d | 0d | start no earlier than 2016-06-07 08:00 | Cave.T; Wang.D | 3.2h |  |
| 28 | 2.4 | LpUCx Installation/Electrical Check | 0.1d | 2016-06-07 09:36 | 2016-06-07 10:24 | 27 |  |  | 60.25d | 0d | start no earlier than 2016-06-07 08:00 | Cave.T; Fisher.C; Wang.D | 2.4h |  |
| 29 | 2.5 | Module Move-TM4-SHC to TCS | 0.2d | 2016-06-07 10:24 | 2016-06-07 12:00 | 28 |  |  | 60.25d | 0d | start no earlier than 2016-06-07 08:00 | Cave.T; Wang.D | 3.2h |  |
| 30 | 2.6 | Module Connection-TM4-TCS/Start of Pumps | 0.2d | 2016-06-07 13:00 | 2016-06-07 14:36 | 29 |  |  | 60.25d | 1.3d | start no earlier than 2016-06-07 08:00 | Wang.D | 1.6h |  |
| 31 | 2.7 | Spent Targt Move | 1d | 2016-06-09 08:00 | 2016-06-09 17:00 | 30 |  |  | 58.95d | 2d | start no earlier than 2016-06-09 08:00 | Cave.T; Fisher.C; Wang.D | 24h |  |
| 32 | 2.8 | Module Disconnection-TM4 -TCS | 0.2d | 2016-06-14 08:00 | 2016-06-14 09:36 | 31 |  |  | 56.95d | 0d | start no earlier than 2016-06-14 08:00 | Wang.D | 1.6h |  |
| 33 | 2.9 | Module Move-TM4-TSC to ITE | 0.2d | 2016-06-14 09:36 | 2016-06-14 11:12 | 32 |  |  | 56.95d | 0d | start no earlier than 2016-06-14 08:00 | Cave.T; Wang.D | 3.2h |  |
| 34 | 2.10 | Module connection-TM4-ITE/Start of Pumps | 0.6d | 2016-06-14 11:12 | 2016-06-14 17:00 | 33 |  |  | 56.95d | 8d | start no earlier than 2016-06-14 08:00 | Wang.D | 4.8h |  |
| 35 | 2.11 | shielding Blocks Transfer ITW to ITE | 1d | 2016-06-27 08:00 | 2016-06-27 17:00 | 34 |  |  | 48.95d | 5d | start no earlier than 2016-06-27 08:00 | Wang.D | 8h |  |

| ID | WBS | Task | Duration | Start | Finish | Predecessors | Total slack | Free slack | Constraint | Resources | Work |
| --- | --- | --- | --- | --- | --- | --- | --- | --- | --- | --- | --- |
| 36 | 3 | **TM2 HpSiC Ready for ITW** | 10d | 2016-07-05 08:00 | 2016-07-18 17:00 |  | 37d |  |  |  | 64h |
| 37 | 3.1 | HpSiC Target Insert into SHC | 0.25d | 2016-07-05 08:00 | 2016-07-05 10:00 | 35 | 43.95d | 0d | start no earlier than 2016-07-05 08:00 | Cave.T; Mjos.A | 4h |
| 38 | 3.2 | Camera Setting up-ITW | 0.25d | 2016-07-05 10:00 | 2016-07-05 12:00 | 37 | 43.95d | 0.25d | start no earlier than 2016-07-05 08:00 | Cave.T | 2h |
| 39 | 3.3 | Module Move_TM2-ITW to SHC | 0.25d | 2016-07-05 15:00 | 2016-07-05 17:00 | 38 | 43.7d | 0d | finish no earlier than 2016-07-05 17:00 | Cave.T; Wang.D | 4h |
| 40 | 3.4 | HpSiC Target Installation/Electrical Check | 0.4d | 2016-07-06 08:00 | 2016-07-06 11:12 | 39 | 43.7d | 0d | start no earlier than 2016-07-05 08:00 | Cave.T; Fisher.C; Wang.D | 9.6h |
| 41 | 3.5 | Module Move-TM2-SHC to TCS | 0.25d | 2016-07-06 11:12 | 2016-07-06 14:12 | 40 | 43.7d | 0d | start no earlier than 2016-07-06 08:00 | Cave.T; Wang.D | 4h |
| 42 | 3.6 | Module Connection-TM2-TSC/Start of Pumps | 0.25d | 2016-07-06 14:12 | 2016-07-06 16:12 | 41 | 43.7d | 0.1d | start no earlier than 2016-07-06 08:00 | Wang.D | 2h |
| 43 | 3.7 | Spent Target Move | 1d | 2016-07-07 08:00 | 2016-07-07 17:00 | 42 | 43.6d | 2d | start no earlier than 2016-07-07 08:00 | Cave.T; Fisher.C; Wang.D | 24h |
| 44 | 3.8 | Module Disconnetion-TM2-TCS | 0.2d | 2016-07-12 08:00 | 2016-07-12 09:36 | 43 | 41.6d | 0.6d | start no earlier than 2016-07-12 08:00 | Wang.D | 1.6h |
| 45 | 3.9 | Module Move-TM2-TCS to ITW | 0.2d | 2016-07-12 15:24 | 2016-07-12 17:00 | 44 | 41d |  | finish no earlier than 2016-07-12 17:00 | Cave.T; Wang.D | 3.2h |
| 46 | 3.10 | Module Connection-TM2-ITW/Start of Pumps | 0.2d | 2016-07-12 15:24 | 2016-07-12 17:00 |  | 39.9d | 3d | finish no earlier than 2016-07-12 17:00 | Wang.D | 1.6h |
| 47 | 3.11 | Shielding Blocks Transfer-ITE to ITW | 1d | 2016-07-18 08:00 | 2016-07-18 17:00 | 46 | 36.9d | 10.9d | start no earlier than 2016-07-18 08:00 | Wang.D | 8h |
| 48 | 4 | **TM4 LP Ucx Ready for ITE** | 10d | 2016-08-02 08:00 | 2016-08-15 17:00 |  | 17d |  |  |  | 53.6h |
| 49 | 4.1 | Lp Ucx target Insert into SHC | 0.1d | 2016-08-02 16:12 | 2016-08-02 17:00 | 47 | 26d |  | finish no earlier than 2016-08-02 17:00 | Fisher.C; Mjos.A | 1.6h |
| 50 | 4.2 | Module Disconnection TM4-ITE | 0.2d | 2016-08-02 08:00 | 2016-08-02 09:36 |  | 26.6d | 0.6d | start no earlier than 2016-08-02 08:00 | Wang.D | 1.6h |
| 51 | 4.3 | Module Move-TM4-ITE to SHC | 0.2d | 2016-08-02 15:24 | 2016-08-02 17:00 | 50 | 26d |  | finish no earlier than 2016-08-02 17:00 | Cave.T; Wang.D | 3.2h |
| 52 | 4.4 | UCx Target Installation/Electrical check-SHC | 0.2d | 2016-08-02 08:00 | 2016-08-02 09:36 |  | 21.8d | 0d | start no earlier than 2016-08-02 08:00 | Cave.T; Fisher.C; Wang.D | 4.8h |
| 53 | 4.5 | Module Move-TM4-SHC to TCS | 0.1d | 2016-08-02 09:36 | 2016-08-02 10:24 | 52 | 21.8d | 0d | start no earlier than 2016-08-02 08:00 | Cave.T; Wang.D | 1.6h |
| 54 | 4.6 | Module Connection-TM4-TCS/Start of Pumps | 0.1d | 2016-08-02 10:24 | 2016-08-02 11:12 | 53 | 21.8d | 1.6d | start no earlier than 2016-08-02 08:00 | Wang.D | 0.8h |
| 55 | 4.7 | Spent Target Move | 1d | 2016-08-04 08:00 | 2016-08-04 17:00 | 54 | 20.2d | 2d | start no earlier than 2016-08-04 08:00 | Cave.T; Fisher.C; Wang.D | 24h |
| 56 | 4.8 | Module Disconnection-TM4-TSC | 0.1d | 2016-08-09 08:00 | 2016-08-09 08:48 | 55 | 18.2d | 0d | start no earlier than 2016-08-09 08:00 | Wang.D | 0.8h |
| 57 | 4.9 | Module Move-TM4-TCS to ITE | 0.2d | 2016-08-09 08:48 | 2016-08-09 10:24 | 56 | 18.2d | 0d | start no earlier than 2016-08-09 08:00 | Cave.T; Wang.D | 3.2h |
| 58 | 4.10 | Module Conenction-TM4-ITE/Start of Pumps | 0.5d | 2016-08-09 10:24 | 2016-08-09 15:24 | 57 | 18.2d | 3.2d | start no earlier than 2016-08-09 08:00 | Wang.D | 4h |
| 59 | 4.11 | shielding Blocks Move | 1d | 2016-08-15 08:00 | 2016-08-15 17:00 | 58 | 15d |  | start no earlier than 2016-08-15 08:00 | Wang.D | 8h |
| 60 | 5 | New Target to SHC | 0.5d | 2016-09-06 08:00 | 2016-09-06 12:00 | 59 | 0d |  | start no earlier than 2016-09-06 08:00 | Fisher.C; Mjos.A | 8h |
| 61 | 6 | Module Disconnection-TM2-ITW | 0.25d | 2016-09-06 13:00 | 2016-09-06 15:00 | 60 | 0d |  | start no earlier than 2016-09-06 08:00 | Wang.D | 2h |
| 62 | 7 | Module Move-TM2-ITW to SHC | 0.25d | 2016-09-06 15:00 | 2016-09-06 17:00 | 61 | 0d |  | start no earlier than 2016-09-06 08:00 | Cave.T; Wang.D | 4h |
| 63 | 8 | New Target Installation/Electrical Check | 0.5d | 2016-09-07 08:00 | 2016-09-07 12:00 | 62 | 0d |  | start no earlier than 2016-09-07 08:00 | Cave.T; Fisher.C; Wang.D | 12h |
| 64 | 9 | Module Move-TM2-SHC to CS/Start of Pumps | 0.5d | 2016-09-07 13:00 | 2016-09-07 17:00 | 63 | 0d |  | start no earlier than 2016-09-07 08:00 | Wang.D | 4h |
